# TextureSync

Schedule from Planner, 2019-03-23 to 2019-06-11.
AI4 - HS Offenburg

## Calendars

- Vorgabe: Mon off; Tue-Wed 08:00-12:00, 13:00-17:00; Thu-Fri off; Sat 08:00-12:00, 13:00-17:00; Sun off.

## Resources

| Resource |
| --- |
| Robin |
| Hendrik |
| Jannik |
| Lukas |

## Schedule

| ID | WBS | Task | Type | Duration | Start | Finish | Predecessors | Complete | Constraint | Resources | Work |
| --- | --- | --- | --- | --- | --- | --- | --- | --- | --- | --- | --- |
| 1 | 1 | **Definition** |  |  | 2019-03-23 | 2019-04-03 |  |  |  |  | 80h |
| 2 | 1.1 | Charta [M] |  |  | 2019-03-23 | 2019-03-23 |  | 100% |  |  | 8h |
| 3 | 1.2 | Lastenheft [M] |  |  | 2019-03-23 | 2019-03-27 |  | 100% |  |  | 24h |
| 4 | 1.3 | Pflichtenheft [M] |  |  | 2019-03-30 | 2019-04-03 | 3 | 100% |  | Lukas | 24h |
| 5 | 1.4 | Risikoanalyse [M] |  |  | 2019-03-30 | 2019-04-03 | 3 | 100% |  | Robin [50%]; Hendrik [50%] | 24h |
| 6 | 2 | **Plannung** |  |  | 2019-04-06 | 2019-04-20 |  |  |  |  | 184h |
| 7 | 2.1 | **Grobdesign [M]** |  |  | 2019-04-06 | 2019-04-09 |  |  |  |  | 24h |
| 8 | 2.1.1 | Architektur festlegen |  |  | 2019-04-06 | 2019-04-09 | 5 | 100% |  | Robin; Hendrik [10%]; Lukas [80%] | 24h |
| 9 | 2.2 | **Feindesign [M]** |  |  | 2019-04-09 | 2019-04-20 |  |  |  |  | 128h |
| 10 | 2.2.1 | 3D Test auf Kotlin + ChipView Test |  |  | 2019-04-09 | 2019-04-16 | 8 | 100% |  | Jannik | 24h |
| 11 | 2.2.2 | Netzwerk-Protokoll definieren |  |  | 2019-04-09 | 2019-04-16 | 8 | 100% |  | Robin | 24h |
| 12 | 2.2.3 | Mockups |  |  | 2019-04-09 | 2019-04-13 | 8 | 100% |  | Jannik | 16h |
| 13 | 2.2.4 | Wie Metadaten filtern? |  |  | 2019-04-17 | 2019-04-20 | 8 | 100% | start no earlier than 2019-04-17 | Robin | 16h |
| 14 | 2.2.5 | Datenerhaltung |  |  | 2019-04-09 | 2019-04-16 | 8 | 100% |  | Lukas | 24h |
| 15 | 2.2.6 | UI Elemente beschreiben |  |  | 2019-04-09 | 2019-04-16 | 8 | 100% |  | Jannik | 24h |
| 16 | 2.3 | Task zuweisen |  |  | 2019-04-09 | 2019-04-10 | 8 | 100% |  |  | 8h |
| 17 | 2.4 | Mastertestplan [M] |  |  | 2019-04-09 | 2019-04-16 | 8 | 100% |  | Hendrik | 24h |
| 18 | 3 | End of Design | milestone | 0d | 2019-04-16 | 2019-04-16 | 11, 10 |  |  |  |  |
| 19 | 4 | **Realisation** |  |  | 2019-04-23 | 2019-05-11 | 18 |  |  |  | 296h |
| 20 | 4.1 | **Einrichtung von Tests** |  |  | 2019-04-23 | 2019-04-23 | 11 |  |  |  | 8h |
| 21 | 4.1.1 | Client Tests |  |  | 2019-04-23 | 2019-04-23 |  |  | start no earlier than 2019-04-23 |  | 8h |
| 22 | 4.2 | **Client** |  |  | 2019-04-23 | 2019-05-04 | 11 |  |  |  | 152h |
| 23 | 4.2.1 | **UI** |  |  | 2019-04-24 | 2019-04-30 | 21 |  |  |  | 80h |
| 24 | 4.2.1.1 | Previews |  |  | 2019-04-24 | 2019-04-30 |  |  |  |  | 24h |
| 25 | 4.2.1.2 | Filter UI |  |  | 2019-04-24 | 2019-04-30 |  |  |  |  | 24h |
| 26 | 4.2.1.3 | 3D Visualisierung |  |  | 2019-04-24 | 2019-04-27 |  | 50% |  |  | 16h |
| 27 | 4.2.1.4 | Dateien hinzufügen |  |  | 2019-04-24 | 2019-04-24 |  |  |  |  | 8h |
| 28 | 4.2.1.5 | Dateien lokal abspeichern |  |  | 2019-04-24 | 2019-04-24 |  |  |  |  | 8h |
| 29 | 4.2.2 | Grund Architektur |  |  | 2019-04-23 | 2019-04-27 |  | 70% | start no earlier than 2019-04-23 | Hendrik [50%]; Jannik [50%] | 24h |
| 30 | 4.2.3 | Protokoll implementieren |  |  | 2019-04-23 | 2019-05-04 |  |  | start no earlier than 2019-04-23 |  | 48h |

| ID | WBS | Task | Type | Duration | Start | Finish | Predecessors | Complete | Constraint | Resources | Work |
| --- | --- | --- | --- | --- | --- | --- | --- | --- | --- | --- | --- |
| 31 | 4.3 | **Server** |  |  | 2019-04-23 | 2019-05-11 | 11 |  |  |  | 136h |
| 32 | 4.3.1 | Dateien speichern/verwalten |  |  | 2019-04-23 | 2019-05-04 |  | 100% | must start on 2019-04-23 |  | 48h |
| 33 | 4.3.2 | Protokoll implementieren |  |  | 2019-04-23 | 2019-05-04 |  | 100% | must start on 2019-04-23 | Robin | 48h |
| 34 | 4.3.3 | Suche implementieren |  |  | 2019-05-07 | 2019-05-11 | 32 | 100% |  |  | 24h |
| 35 | 4.3.4 | Hauptlogik implementieren |  |  | 2019-05-07 | 2019-05-08 | 33, 32 | 100% |  |  | 16h |
| 36 | 5 | End of Implementation | milestone | 0d | 2019-05-11 | 2019-05-11 | 31, 22, 20 |  |  |  |  |
| 37 | 6 | **Abnahme** |  |  | 2019-05-14 | 2019-06-11 |  |  |  |  | 104h |
| 38 | 6.1 | Modultests [M] |  |  | 2019-05-14 | 2019-05-21 | 36 |  |  |  | 32h |
| 39 | 6.2 | Integrationstests [M] |  |  | 2019-05-22 | 2019-05-29 | 38 |  |  |  | 32h |
| 40 | 6.3 | Systemtests [M] |  |  | 2019-06-01 | 2019-06-08 | 39 |  |  |  | 32h |
| 41 | 6.4 | Akzeptanztest [M] |  |  | 2019-06-11 | 2019-06-11 | 40 |  |  |  | 8h |

Notes:
- 35: Hauptsächlich Glue-Code
